# CoastalPF-ver0

Schedule from MS Project, 2012-01-02 to 2013-04-05.

## Calendars

- Standard: Mon-Fri 08:00-12:00, 13:00-17:00; Sat-Sun off.

## Resources

| Resource |
| --- |
| Wayne |
| Gene |
| Mike |
| Ken |

## Schedule

| ID | WBS | Task | Duration | Start | Finish | Predecessors | Total slack | Free slack | Constraint | Resources | Work |
| --- | --- | --- | --- | --- | --- | --- | --- | --- | --- | --- | --- |
| 1 | 1 | Define Science Req'ts | 1.43d | 2012-01-02 | 2012-01-03 |  | 327.86d |  |  | Gene [70%] | 8h |
| 2 | 2 | Define Engr Req'ts | 1.43d | 2012-01-02 | 2012-01-03 |  | 327.86d |  |  | Gene [70%] | 8h |
| 3 | 3 | **Preliminary Design** | 129.29d | 2012-01-02 | 2012-06-29 |  | 0d |  |  |  | 760h |
| 4 | 3.1 | Preliminary Design | 71.43d | 2012-01-02 | 2012-04-10 |  | 0d |  |  | Gene [70%] | 400h |
| 5 | 3.2 | **Prototype risky elements** | 57.86d | 2012-04-10 | 2012-06-29 |  | 0d |  |  |  | 360h |
| 6 | 3.2.1 | Build proto fixtures | 15d | 2012-04-10 | 2012-05-01 | 4 | 0d |  |  | Mike | 120h |
| 7 | 3.2.2 | BE pump/cylinder | 14.29d | 2012-05-01 | 2012-05-21 | 6 | 0d |  |  | Gene [70%] | 80h |
| 8 | 3.2.3 | BE pump/bladder/cylinder | 14.29d | 2012-05-21 | 2012-06-08 | 7 | 0d |  |  | Gene [70%] | 80h |
| 9 | 3.2.4 | uP GPS/motor control | 14.29d | 2012-06-08 | 2012-06-29 | 8 | 0d |  |  | Gene [70%] | 80h |
| 10 | 4 | long term proto tests | 200d | 2012-06-29 | 2013-04-05 | 8, 9 | 0d |  |  | Gene [1%] | 16h |
| 11 | 5 | PDR | 1.43d | 2012-06-29 | 2012-07-02 | 4, 5 | 129d | 0d |  | Gene [70%] | 8h |
| 12 | 6 | Build test tank prototype | 20d | 2012-07-02 | 2012-07-30 | 11 | 129d | 0d |  | Mike | 160h |
| 13 | 7 | test TT proto | 28.57d | 2012-07-30 | 2012-09-07 | 12 | 150d |  |  | Gene [70%] | 160h |
| 14 | 8 | Initial software development | 150d | 2012-05-31 | 2012-12-26 |  | 71.29d |  | start no earlier than 2012-05-31 | Wayne [40%] | 480h |
| 15 | 9 | **CDR** | 1d? | 2012-07-16 | 2012-07-17 | 12SS+10d | 129d |  |  | Gene [70%] | 9.6h |
| 16 | 9.1 | Define first article mission | 1d? | 2012-07-16 | 2012-07-17 |  | 129d | 0d |  | Ken [50%] | 4h |
| 17 | 10 | First article design | 28.57d | 2012-07-17 | 2012-08-27 | 16 | 129d | 0d |  | Gene [70%] | 160h |
| 18 | 11 | Build FA | 30d? | 2012-08-27 | 2012-10-08 | 17 | 129d |  |  | Mike | 240h |
| 19 | 12 | Build PF tracking app | 14.29d? | 2012-08-27 | 2012-09-14 | 17 | 129.43d | 0d |  | Gene [70%] | 80h |
| 20 | 13 | Tank test FA | 14.29d? | 2012-09-14 | 2012-10-04 | 19 | 129.43d | 0d |  | Gene [70%] | 80h |
| 21 | 14 | Deploy FA | 60d? | 2012-10-04 | 2012-12-27 | 20, 19 | 70.43d |  |  | Gene [50%] | 240h |
